# Projektplan mFund envVisio-GI

Schedule from GanttProject, 2020-09-14 to 2022-11-30.

## Calendars

- Project calendar: Mon-Fri working; Sat-Sun off.

## Resources

| Resource |
| --- |
| Fachhochschule Erfurt (FHE) |
| Kreis Lippe (LIP) |
| Stadt Leipzig (L) |
| Vogelsbergkreis (VK) |
| Stadt Dresden (DD) |
| Bundesamt für Kartographie und Geodäsie (BKG) |
| M.O.S.S. GmbH (MOSS) |
| Simplex4Data GmbH (S4D) |
| HRD Consulting (HRD) |
| Scopeland Technology GmbH (SCL) |

## Schedule

| ID | WBS | Task | Type | Duration | Start | Finish | Predecessors | Resources |
| --- | --- | --- | --- | --- | --- | --- | --- | --- |
| 1 | 1 | **Projektkoordination** |  | 244d | 2020-09-15 | 2021-08-20 |  |  |
| 2 | 1.1 | Regelmäßige Treffen der AG Anwendungsfall organisieren |  | 26d | 2020-09-15 | 2020-10-20 |  | Bundesamt für Kartographie und Geodäsie (BKG) |
| 3 | 1.2 | AG Anwendungsfall Treffen Termin | milestone | 0d | 2020-10-21 | 2020-10-21 | 2 | Fachhochschule Erfurt (FHE); Kreis Lippe (LIP); Stadt Leipzig (L); Vogelsbergkreis (VK); Stadt Dresden (DD); Bundesamt für Kartographie und Geodäsie (BKG); M.O.S.S. GmbH (MOSS); Simplex4Data GmbH (S4D); Scopeland Technology GmbH (SCL) |
| 4 | 1.3 | Gesamtprojekttreffen Terminfindung |  | 21d | 2020-12-01 | 2020-12-29 |  |  |
| 5 | 1.4 | Lizenzschließung mit DLZ zur Datennutzung |  | 16d | 2021-01-04 | 2021-01-25 |  |  |
| 6 | 1.5 | Konsortialmeeting mit Projektträger |  | 10d | 2021-08-09 | 2021-08-20 |  |  |
| 7 | 1.6 | **Unterarbeitspaketkoordination** |  | 168d | 2020-12-02 | 2021-07-23 |  |  |
| 8 | 1.6.1 | Gespräche zu AP2 (Datenimport) |  | 6d | 2020-12-02 | 2020-12-09 |  | Kreis Lippe (LIP); Stadt Leipzig (L); Vogelsbergkreis (VK); Stadt Dresden (DD); Bundesamt für Kartographie und Geodäsie (BKG); Simplex4Data GmbH (S4D); Scopeland Technology GmbH (SCL) |
| 9 | 1.6.2 | Gespräche zu AP5 organisieren (Services und APIs) |  | 6d | 2021-03-08 | 2021-03-15 |  | Bundesamt für Kartographie und Geodäsie (BKG); M.O.S.S. GmbH (MOSS) |
| 10 | 1.6.3 | Nicht Haupt-AP Aufgaben koordiniert | milestone | 0d | 2021-03-16 | 2021-03-16 | 8, 9 | Bundesamt für Kartographie und Geodäsie (BKG) |
| 11 | 1.6.4 | Gespräch zu 7.1 (Konzeption und Spezifikation) |  | 6d | 2020-12-18 | 2020-12-25 |  | Fachhochschule Erfurt (FHE); Kreis Lippe (LIP); Stadt Leipzig (L); Vogelsbergkreis (VK); Stadt Dresden (DD); Bundesamt für Kartographie und Geodäsie (BKG) |
| 12 | 1.6.5 | Gespräch zu 7.4 (Spezifikation des Datenmanagments) |  | 7d | 2020-12-25 | 2021-01-04 |  | Kreis Lippe (LIP); Stadt Leipzig (L); Vogelsbergkreis (VK); Stadt Dresden (DD); Bundesamt für Kartographie und Geodäsie (BKG); M.O.S.S. GmbH (MOSS); Simplex4Data GmbH (S4D) |
| 13 | 1.6.6 | Gespräch zu 7.5 (Implementierung von Anwendungsszenarien) |  | 5d | 2021-07-19 | 2021-07-23 |  | Bundesamt für Kartographie und Geodäsie (BKG); Scopeland Technology GmbH (SCL) |
| 14 | 2 | **Berichtspflichten** |  | 432d | 2021-04-05 | 2022-11-29 |  |  |
| 15 | 2.1 | Zwischenbericht I |  | 19d | 2021-04-05 | 2021-04-29 |  |  |
| 16 | 2.2 | Zwischenbericht I eingereicht | milestone | 0d | 2021-04-30 | 2021-04-30 | 15 |  |
| 17 | 2.3 | Zwischenbericht II |  | 19d | 2022-04-04 | 2022-04-28 |  |  |
| 18 | 2.4 | Zwischenbericht II eingereicht | milestone | 0d | 2022-04-29 | 2022-04-29 | 17 |  |
| 19 | 2.5 | Schlussbericht |  | 17d | 2022-11-07 | 2022-11-29 |  |  |
| 20 | 2.6 | Schlussbericht eingereicht | milestone | 0d | 2022-11-30 | 2022-11-30 | 19 |  |
| 21 | 3 | **AP7 (Anwendungsfall Klima und Mobilität)** |  | 445d | 2020-09-15 | 2022-05-30 |  |  |
| 22 | 3.1 | Präsentation über GDI Dokumente & Anforderungen |  | 1d | 2020-09-21 | 2020-09-21 |  | Bundesamt für Kartographie und Geodäsie (BKG) |
| 23 | 3.2 | Relevante GDI Dokumente den Projektpartnern bekannt | milestone | 0d | 2020-09-22 | 2020-09-22 | 22 |  |
| 24 | 3.3 | Erste Eruierungen der Anforderungen Anwendungsfall Klima&Mobilität |  | 26d | 2020-09-15 | 2020-10-20 |  |  |
| 25 | 3.4 | Bereich im GDI-DE Wiki zur Kommunikation und Organisation erstellt | milestone | 0d | 2020-10-20 | 2020-10-20 |  | Bundesamt für Kartographie und Geodäsie (BKG) |
| 26 | 3.5 | Dokumentation des Anwendungsfalls (Klima&Mobilität + inhaltlich&funktional) |  | 420d | 2020-10-20 | 2022-05-30 | 25 | Kreis Lippe (LIP); Stadt Leipzig (L); Vogelsbergkreis (VK); Stadt Dresden (DD); Bundesamt für Kartographie und Geodäsie (BKG) |
| 27 | 3.6 | Schärfung der Anforderungen |  | 29d | 2020-10-22 | 2020-12-01 | 24FS+1d | Kreis Lippe (LIP); Stadt Leipzig (L); Vogelsbergkreis (VK); Stadt Dresden (DD) |
| 28 | 3.7 | Ausarbeitung der Anwendungsszenarien |  | 68d | 2020-12-02 | 2021-03-05 | 27 |  |
| 29 | 3.8 | Erste ausgearbeitete Version von Anwendungsfällen der Projektpartner | milestone | 0d | 2021-03-08 | 2021-03-08 | 28 | Kreis Lippe (LIP); Stadt Leipzig (L); Vogelsbergkreis (VK); Stadt Dresden (DD) |
| 30 | 3.9 | Vorformulierung (SMARTer) Szenarien |  | 65d | 2021-03-05 | 2021-06-03 |  | Fachhochschule Erfurt (FHE); Kreis Lippe (LIP); Stadt Leipzig (L); Vogelsbergkreis (VK); Stadt Dresden (DD); Bundesamt für Kartographie und Geodäsie (BKG) |
| 31 | 3.10 | UAP 7.3 (Datenbereitstellung und Visualisierung) |  | 65d | 2021-03-05 | 2021-06-03 |  | Fachhochschule Erfurt (FHE); Kreis Lippe (LIP); Stadt Leipzig (L); Vogelsbergkreis (VK); Stadt Dresden (DD); Bundesamt für Kartographie und Geodäsie (BKG) |
| 32 | 3.11 | SMARTe Ausarbeitung der Anwendungsfälle |  | 57d | 2021-06-14 | 2021-08-31 | 30, 31 |  |
| 33 | 3.12 | Konsolidierte Ausarbeitung der Anwendungsfälle | milestone | 0d | 2021-09-01 | 2021-09-01 | 32 |  |

Notes:
- 2: UAP 1.1 Projektkoordination
- 3: Jeden ersten Dienstag im Monat um 13:00 Uhr. / Infos zu den Teilnehmern im Ressourcentab.
- 4: UAP 1.1 Projektkoordination / Terminfindung für ein Treffen mit allen beteiligten Projektpartnern. / Informationsautasch innerhalb des Projekts zu zäh.
- 5: DLZ benötigt: / - Name des Projektes / - Förderzeitraum bzw. Projektlaufzeit / - Inhalt bzw. Projektziel (für die genannten Punkte kann ggf. ein Link angegeben werden, sofern die verlinkte Webseite die entsprechenden Informationen enthält) / - Vornamen, Namen, Email-Adressen, Telefonnummern und Adressen von Ansprechpartnern für Vertragliches, Technisches und Bestellungen (hier ist es unproblematisch, wenn einen Person mehrere Rollen übernimmt, was intern natürlich vorher seitens der Projektverantwortlichen geklärt werden muss; zumindest ein Ansprechpartner für Vertragliches muss genannt werden)
- 8: Terminfindung und anschließende Klärung welche Aufgaben das BKG bei / UAP 2.1 (Datenmapping und Modellanpassungen) und / UAP 2.2 (Ausführen der Datenimporte) hat.
- 9: Terminfindung und anschließende Klärung welche Aufgaben das BKG bei / UAP 5.1 (Entwicklung von Web Diensten für den Datenabruf) hat.
- 10: Alle Aufgaben, die nicht in den betreuten Arbeitspaketen 7 & 8 liegen wurden geklärt bzw. abgeschlossen. / --> Die Hauptaufgabe des BKG im AP2 ist die Datenbereitstellung und Klärung unterwelchen Bedingungen gewisse Datensätze zur Verfügung gestellt werden können
- 11: - Erstellen der Sichten für INSPIRE, Berichte, Fachauskünfte und andere Datenbereitstellungen / - Erstellen der Sichten für den Anwendungsfall Klima und Mobilität / Was ist mit den Arbeitsschritten gemeint? / --> Datenbank Views für INSPIRE etc. aus Standards/Richtlinien / --> Datenbank Views für Kommunen anhand der Anwendungsfälle individuell festzulegen
- 12: Terminfindung und anschließende Klärung welche Aufgaben das BKG bei / UAP 7.4 (Spezifikation des Datenmanagments) hat. / -->keine gesonderte Hilfe neben der Koordinierung seitens BKG nötig
- 13: Ist Hilfe seitens des BKGs zu diesem Punkt notwendig?
- 23: Die Projektpartner bekennen sich dazu, Standards und Vorgaben der GDI-DE und INSPIRE einzuhalten. / Relevante Dokumente unter (UAP 7.1): / https://wiki.gdi-de.org/pages/viewpage.action?pageId=757764338
- 24: Erste Inputs: / - Vogelsbergkreis: Harmonisierung von Gebäudedaten / - Leipzig: Prozessoptimierung der Erstellung von Lärmkarten ( Harmonisierung der erforderlichen Daten und Verschneidung/Erzeugung) / - Lippe: inteligentes / Kommunenübergreifendes Verkehrsmanagement ... / - Dresden: noch offen. Bereitstellung von POI Informationen ...
- 25: Offener Bereich im GDI-DE Wiki für alle Projektpartner zugänglich (1 Zugang pro Partner) / Für jedes AP sind bereits eigene Seiten eingerichtet. / Für Datenbedarfe und bereits bekannte Quellen ist unter AP7 eine Tabelle hinterlegt: / https://wiki.gdi-de.org/pages/viewpage.action?pageId=760643802 / hier sollen Bedarfe und bereits bekannte Quellen durch alle Projektpartner ergänzt werden.
- 26: Die Dokumentation findet im GDI-DE Wiki statt und soll sich an der Dokumentation der Fachnetzwerke/technischer Umsetzung orientieren. / Um eine Nachnutzung zu gewährleisten ist eine umfangreiche Dokumentation (auch der Arbeitsschritte) notwendig. Dokumentation muss abstrahierbar sein (7.2).
- 27: Bereitgestellte Strukturen im GDI-DE Wiki sollen genutzt werden um Fälle zu diskutieren und auszuarbeiten.
- 28: Bis zum AG Anwendungsfall Treffen am 05.01.2021 sollen erste konkretere Anwendungsfälle der Projektpartner formuliert sein. / Fall: Zukunftskonzept 2025 Lippe / Fall: Harmonisierung von Gebäudedaten VBK / Fall: Prozessoptimierung Lärmkartierung Leipzig / Fall: ?
- 29: Sobald jeder kommunale Partner einen Anwendungsfall formuliert hat, kann damit begonnen werden, SMARTe Ziele für diese zu stecken. / Status Lippe: Projektabsprachen laufen; Update Mitte Januar / Status Leipzig: Dokumentation läuft / Status Vogelsbergkreis: i.A. / Status Dresden: i.A.
- 30: inkl. Gespräche mit Technik ob realisierbar / S – Spezifisch / M – Messbar / A – Akzeptiert / R – Realistisch / T – Terminierbar
- 31: UAP 7.3: Anforderungen für Datenbereitstellung (gemäß INSPIRE und GDI-DE) sowie an die Visualisierung der Ergebnisse (Technik und Dokumentation) müssen vertieft werden. / Diese werden dokumentiert. / Welche Vorstellungen haben die kommunalen Partner? / Was ist mit der Technik möglich? / --> Gespräche mit Technik und Kommunen
- 33: UAP 7.2

| ID | WBS | Task | Type | Duration | Start | Finish | Predecessors | Resources |
| --- | --- | --- | --- | --- | --- | --- | --- | --- |
| 34 | 4 | **AP8 (Qualitätssicherung und Verwertung)** |  | 263d | 2021-03-08 | 2022-03-09 |  | Bundesamt für Kartographie und Geodäsie (BKG) |
| 35 | 4.1 | Erstellung Qualitätsplan |  | 43d | 2021-03-08 | 2021-05-05 |  |  |
| 36 | 4.2 | Qualitätskonzept erarbeitet | milestone | 0d | 2021-05-06 | 2021-05-06 | 35 |  |
| 37 | 4.3 | Überprüfung der Dokumentation |  | 175d | 2021-05-03 | 2021-12-31 |  |  |
| 38 | 4.4 | Dokumente zur Nachnutzung stehen bereit | milestone | 0d | 2022-01-03 | 2022-01-03 | 37 |  |
| 39 | 4.5 | Überprüfung der Datanbank auf Anforderungen der GDI-DE und Projektpartner |  | 44d | 2021-08-02 | 2021-09-30 | 44, 47 |  |
| 40 | 4.6 | Überprüfung der importierten Daten |  | 44d | 2021-08-02 | 2021-09-30 |  |  |
| 41 | 4.7 | Überprüfung der Anwendung |  | 127d | 2021-09-01 | 2022-02-24 | 48SS |  |
| 42 | 4.8 | Vergleich der finalen Anwendung mit SMART-Zielen |  | 6d | 2022-03-02 | 2022-03-09 | 49 |  |
| 43 | 5 | **Technische Vorgänge** |  | 382d | 2020-09-14 | 2022-03-01 |  |  |
| 44 | 5.1 | AP2 (Datenimport) |  | 189d | 2020-09-14 | 2021-06-03 |  | HRD Consulting (HRD) |
| 45 | 5.2 | Dateneinsicht Kreis Lippe | milestone | 0d | 2021-08-05 | 2021-08-05 |  |  |
| 46 | 5.3 | Erste Datensichtungen | milestone | 0d | 2021-06-03 | 2021-06-03 |  |  |
| 47 | 5.4 | Zentrale Datenbank mit allen benötigten Daten | milestone | 0d | 2021-08-02 | 2021-08-02 | 44 |  |
| 48 | 5.5 | UAP 7.5 (Implementierung von Anwendungsszenarien) |  | 78d | 2021-08-31 | 2021-12-16 | 13 |  |
| 49 | 5.6 | Anwendungen sind Betriebsbereit | milestone | 0d | 2022-03-02 | 2022-03-02 | 41, 48 |  |
| 50 | 6 | **Hackathon** |  | 200d | 2021-08-23 | 2022-05-27 |  | Fachhochschule Erfurt (FHE); Bundesamt für Kartographie und Geodäsie (BKG) |
| 51 | 6.1 | Organisation Hackathon |  | 198d | 2021-08-23 | 2022-05-25 |  |  |
| 52 | 6.2 | Hackathon Durchführung |  | 2d | 2022-05-26 | 2022-05-27 | 51 |  |

Notes:
- 35: Sinnvolle Testszenarios für die Anwendungsfälle bestimmen
- 40: Werkzeuge: / - INSPIRE Validator / - Testsuite
- 41: Benutzung von GIS um Anwendungen/Daten/Dienste zu testen.
- 42: Relative Qualität des erreichten Zustands zu vorformulierten Zielen.
- 46: laut Rudolf
- 50: Wenn ein Hackathon bereits Mitte 2021 gewünscht/möglich ist uU Absprache mit F.Würriehausen zwecks Synergien. / 1. Projektleitung / 2. Falk
- 51: Hackathon soll zum Abschluss des Projektes stattfinden. / Verwendet werden im Optimalfall, Daten und Dienste die durch das envVisio-GI Projekt erarbeitet werden konnten.
